# HRA Project Plan

Schedule from MS Project, 2011-10-31 to 2012-11-19, A marks actual dates.
Microsoft

## Calendars

- Standard: Mon-Fri 08:00-12:00, 13:00-17:00; Sat-Sun off. Exceptions (off unless hours are given): 2011-11-24 (Thanksgiving Day), 2011-11-25 (Thanksgiving Friday), 2011-12-23 (Special MIT Holiday 1), 2011-12-26 (Christmas Day Observed), 2011-12-30 (Special MIT Holiday 2), 2012-01-02 (New Years Day Observed), 2012-01-16 (Martin Luther King Birthday), 2012-02-20 (Presidents Day).

## Resources

| Resource |
| --- |
| Ross |
| Jonathan |
| Robin |
| Janet |

## Schedule

| ID | WBS | Task | Type | Duration | Start | Finish | Predecessors | Complete | Remaining | Total slack | Constraint | Resources | Work | Actual work |
| --- | --- | --- | --- | --- | --- | --- | --- | --- | --- | --- | --- | --- | --- | --- |
| 1 | 1 | **Housing Replacement Analysis Project** |  | 268d | 2011-10-31 A | 2012-11-19 |  | 6% | 252.18d | 0d |  |  | 1752.64h | 204.32h |
| 2 | 1.1 | Project Kickoff Meeting |  | 1d | 2011-10-31 | 2011-10-31 |  |  |  | 305.5d |  |  |  |  |
| 3 | 1.2 | **Discovery Phase (as-is)** |  | 164d | 2011-11-04 A | 2012-07-02 |  | 8% | 151.64d | 0d |  |  | 1752.64h | 204.32h |
| 4 | 1.2.1 | **Business Justification** |  | 20d | 2011-11-04 A | 2011-12-06 A | 2 | 100% |  |  |  |  | 136h | 136h |
| 5 | 1.2.1.1 | Write Business Justification |  | 10d | 2011-11-14 A | 2011-11-25 A | 6 | 100% |  |  | start no earlier than 2011-11-01 | Jonathan | 80h | 80h |
| 6 | 1.2.1.2 | Review Business Justification |  | 6d | 2011-11-04 A | 2011-11-11 A |  | 100% |  |  | finish no earlier than 2011-11-11 | Jonathan | 48h | 48h |
| 7 | 1.2.1.3 | Obtain Approval from Project Team |  | 1d | 2011-11-29 A | 2011-11-29 A | 5, 6 | 100% |  |  | start no earlier than 2011-11-29 | Jonathan | 8h | 8h |
| 8 | 1.2.1.4 | Obtain Approval from Project Sponsors | milestone | 0d | 2011-12-06 A | 2011-12-06 A | 7 | 100% |  |  | start no earlier than 2011-12-06 | Jonathan |  |  |
| 9 | 1.2.1.5 | Business Justification completed | milestone | 0d | 2011-12-06 A | 2011-12-06 A | 8 | 100% |  |  |  | Jonathan |  |  |
| 10 | 1.2.2 | **Project Scope Document** |  | 19d | 2011-11-07 A | 2011-12-06 A | 2 | 100% |  |  |  |  | 56h | 56h |
| 11 | 1.2.2.1 | Write Project Scope Document |  | 5d | 2011-11-07 A | 2011-11-11 A |  | 100% |  |  | finish no earlier than 2011-11-11 | Jonathan | 40h | 40h |
| 12 | 1.2.2.2 | Review Project Scope Document |  | 1d | 2011-11-18 A | 2011-11-18 A | 11 | 100% |  |  | finish no earlier than 2011-11-18 | Jonathan | 8h | 8h |
| 13 | 1.2.2.3 | Obtain Approval from Project Team |  | 1d | 2011-11-29 A | 2011-11-29 A |  | 100% |  |  | start no earlier than 2011-11-29 | Jonathan | 8h | 8h |
| 14 | 1.2.2.4 | Obtain Approval from Project Sponsors | milestone | 0d | 2011-12-06 A | 2011-12-06 A |  | 100% |  |  | start no earlier than 2011-12-06 | Jonathan |  |  |
| 15 | 1.2.2.5 | Project Scope completed | milestone | 0d | 2011-12-06 A | 2011-12-06 A |  | 100% |  |  | start no earlier than 2011-12-06 | Jonathan |  |  |
| 16 | 1.2.3 | **Discovery Meetings** |  | 92d | 2011-12-15 A | 2012-04-30 | 4, 10 | 2% | 90.17d | 0d |  |  | 1048.64h | 12.32h |
| 17 | 1.2.3.1 | System Diagram (IS&T) |  | 7d | 2011-12-15 A | 2012-02-03 |  | 50% | 3.5d | 60d | finish no earlier than 2012-02-03 | Ross [44%] | 24.64h | 12.32h |
| 18 | 1.2.3.2 | **Housing / Lottery** |  | 73d | 2011-12-15 | 2012-04-03 |  |  |  | 19d |  |  | 156.8h |  |
| 19 | 1.2.3.2.1 | Freshman (new to the Institute) |  | 2d | 2011-12-15 | 2011-12-16 |  |  |  | 90d | start no earlier than 2011-12-15 | Ross [40%] | 6.4h |  |
| 20 | 1.2.3.2.2 | Upperclassman |  | 2d | 2012-04-02 | 2012-04-03 |  |  |  | 19d | start no earlier than 2012-04-02 | Ross [40%] | 6.4h |  |
| 21 | 1.2.3.2.3 | FSILG |  | 2d | 2012-04-02 | 2012-04-03 |  |  |  | 19d | start no earlier than 2012-04-02 | Ross | 16h |  |
| 22 | 1.2.3.2.4 | Off Campus Students |  | 2d | 2012-04-02 | 2012-04-03 |  |  |  | 19d | start no earlier than 2012-04-02 | Ross | 16h |  |
| 23 | 1.2.3.2.5 | Graduate Students |  | 2d | 2012-04-02 | 2012-04-03 |  |  |  | 19d | start no earlier than 2012-04-02 | Ross | 16h |  |
| 24 | 1.2.3.2.6 | Summer Students |  | 2d | 2012-04-02 | 2012-04-03 |  |  |  | 19d | start no earlier than 2012-04-02 | Ross | 16h |  |
| 25 | 1.2.3.2.7 | Post-Doctoral / Faculty |  | 2d | 2012-04-02 | 2012-04-03 |  |  |  | 19d | start no earlier than 2012-04-02 | Ross | 16h |  |
| 26 | 1.2.3.2.8 | Young Students (Legal Minors) |  | 2d | 2012-04-02 | 2012-04-03 |  |  |  | 19d | start no earlier than 2012-04-02 | Ross | 16h |  |
| 27 | 1.2.3.2.9 | Outside, Non Affiliated Groups |  | 2d | 2012-04-02 | 2012-04-03 |  |  |  | 19d | start no earlier than 2012-04-02 | Ross | 16h |  |
| 28 | 1.2.3.2.10 | MIT - Affiliated Groups |  | 2d | 2012-04-02 | 2012-04-03 |  |  |  | 19d | start no earlier than 2012-04-02 | Ross | 16h |  |
| 29 | 1.2.3.2.11 | Visitors |  | 2d | 2012-04-02 | 2012-04-03 |  |  |  | 19d | start no earlier than 2012-04-02 | Ross | 16h |  |

| ID | WBS | Task | Duration | Start | Finish | Predecessors | Total slack | Free slack | Constraint | Resources | Work |
| --- | --- | --- | --- | --- | --- | --- | --- | --- | --- | --- | --- |
| 30 | 1.2.3.3 | **Housing filemaker Databases** | 10d | 2012-02-06 | 2012-02-17 |  | 50d |  |  |  | 192h |
| 31 | 1.2.3.3.1 | Master Blaster | 5d | 2012-02-06 | 2012-02-10 |  | 55d |  | start no earlier than 2012-02-06 | Janet | 40h |
| 32 | 1.2.3.3.2 | UG Confirmation | 5d | 2012-02-06 | 2012-02-10 |  | 55d |  | start no earlier than 2012-02-06 | Ross [40%] | 16h |
| 33 | 1.2.3.3.3 | Conference / Guest | 5d | 2012-02-06 | 2012-02-10 |  | 50d | 0d | start no earlier than 2012-02-06 | Ross [40%] | 16h |
| 34 | 1.2.3.3.4 | Vacancy | 5d | 2012-02-13 | 2012-02-17 |  | 50d |  | start no earlier than 2012-02-13 | Janet | 40h |
| 35 | 1.2.3.3.5 | Early Return | 5d | 2012-02-13 | 2012-02-17 |  | 50d |  | start no earlier than 2012-02-13 | Ross | 40h |
| 36 | 1.2.3.3.6 | Waiting List | 5d | 2012-02-13 | 2012-02-17 |  | 50d |  | start no earlier than 2012-02-13 | Janet | 40h |
| 37 | 1.2.3.3.7 | Front Desk | 5d | 2012-02-13 | 2012-02-17 | 33 | 50d |  |  |  |  |
| 38 | 1.2.3.4 | Housing SISTIM Functionality on Housing | 8d | 2012-02-21 | 2012-03-01 |  | 42d |  | start no earlier than 2012-02-21 | Ross | 64h |
| 39 | 1.2.3.5 | Housing MITSIS Functionality on Housing | 8d | 2012-02-21 | 2012-03-01 |  | 0d |  | start no earlier than 2012-02-21 | Janet | 64h |
| 40 | 1.2.3.6 | **Housing Stakeholder - HFS Accounting (David Bull's Group)** | 5d | 2012-03-02 | 2012-03-08 | 39 | 0d |  |  |  | 240h |
| 41 | 1.2.3.6.1 | Discuss systems/applications/process flow | 5d | 2012-03-02 | 2012-03-08 |  | 0d |  |  | Janet | 40h |
| 42 | 1.2.3.6.2 | Discuss process calendar | 5d | 2012-03-02 | 2012-03-08 |  | 0d |  |  | Janet | 40h |
| 43 | 1.2.3.6.3 | Walkthrough of digital Building/Room Setup & Maintenance | 5d | 2012-03-02 | 2012-03-08 |  | 0d |  |  | Janet | 40h |
| 44 | 1.2.3.6.4 | Walkthrough of Room Rate Codes Setup & Maintenance | 5d | 2012-03-02 | 2012-03-08 |  | 0d |  |  | Janet | 40h |
| 45 | 1.2.3.6.5 | Analysis/review of OTF process | 5d | 2012-03-02 | 2012-03-08 |  | 0d |  |  | Janet | 40h |
| 46 | 1.2.3.6.6 | Discuss functionality/efficiency/information gaps in current assessment & OTF process | 5d | 2012-03-02 | 2012-03-08 |  | 0d |  |  | Janet | 40h |
| 47 | 1.2.3.7 | **Housing Stakeholder - Student Financial Services** | 5d | 2012-03-12 | 2012-03-16 | 40FS+1d | 0d |  |  |  | 48h |
| 48 | 1.2.3.7.1 | Assess primary users/roles | 5d | 2012-03-12 | 2012-03-16 |  | 0d |  |  | Ross [40%] | 16h |
| 49 | 1.2.3.7.2 | Discuss systems/process flow | 5d | 2012-03-12 | 2012-03-16 |  | 0d |  |  | Ross [40%] | 16h |
| 50 | 1.2.3.7.3 | Discuss process calendar | 5d | 2012-03-12 | 2012-03-16 |  | 0d |  |  | Ross [40%] | 16h |
| 51 | 1.2.3.8 | **Housing Stakeholder - Registrar** | 5d | 2012-03-20 | 2012-03-26 | 47FS+1d | 0d |  |  |  | 120h |
| 52 | 1.2.3.8.1 | Evaluate scope of affected data/process/systems | 5d | 2012-03-20 | 2012-03-26 |  | 0d |  |  | Janet | 40h |
| 53 | 1.2.3.8.2 | Examine dataflow for MITSIS Directory information | 5d | 2012-03-20 | 2012-03-26 |  | 0d |  |  | Janet | 40h |
| 54 | 1.2.3.8.3 | Examine current supporting processes & functionality | 5d | 2012-03-20 | 2012-03-26 |  | 0d |  |  | Janet | 40h |
| 55 | 1.2.3.9 | Housing Stakeholders - Card Office | 5d | 2012-03-27 | 2012-04-02 | 51 | 0d |  |  | Ross [40%] | 16h |
| 56 | 1.2.3.10 | Housing Stakeholders - Security and Emergency Office | 5d | 2012-04-03 | 2012-04-09 | 55 | 0d |  |  | Janet | 40h |
| 57 | 1.2.3.11 | Housing Stakeholders - Campus Dining | 5d | 2012-04-10 | 2012-04-16 | 56 | 0d |  |  | Ross [40%] | 16h |

| ID | WBS | Task | Type | Duration | Start | Finish | Predecessors | Total slack | Constraint | Resources | Work |
| --- | --- | --- | --- | --- | --- | --- | --- | --- | --- | --- | --- |
| 58 | 1.2.3.12 | **CBORD** |  | 10d | 2012-04-17 | 2012-04-30 | 57 | 0d |  |  | 67.2h |
| 59 | 1.2.3.12.1 | Digital Building / Room Setup & Maintenance |  | 10d | 2012-04-17 | 2012-04-30 |  | 0d | start no earlier than 2012-01-23 | Ross [40%] | 32h |
| 60 | 1.2.3.12.2 | Room Rate Code Setup & Maintenance |  | 1d | 2012-04-17 | 2012-04-17 |  | 9d | start no earlier than 2012-03-05 | Ross [40%] | 3.2h |
| 61 | 1.2.3.12.3 | Current Security, Roles & Authorization, and structures for housing applications |  | 10d | 2012-04-17 | 2012-04-30 |  | 0d | start no earlier than 2012-03-05 | Ross [40%] | 32h |
| 62 | 1.2.4 | **Discovery Phase Documentation** |  | 50d | 2012-04-17 | 2012-06-25 | 16FS-10d | 0d |  |  | 512h |
| 63 | 1.2.4.1 | **As-Is Process Maps** |  | 30d | 2012-04-17 | 2012-05-28 |  | 0d |  |  | 192h |
| 64 | 1.2.4.1.1 | Graduate Students |  | 10d | 2012-04-17 | 2012-04-30 |  | 0d | start no earlier than 2012-02-17 | Janet [40%] | 32h |
| 65 | 1.2.4.1.2 | Undergraduate Students |  | 10d | 2012-04-17 | 2012-04-30 |  | 0d | start no earlier than 2012-02-17 | Ross [40%] | 32h |
| 66 | 1.2.4.1.3 | Vacancy |  | 10d | 2012-05-01 | 2012-05-14 | 64 | 0d | start no earlier than 2012-02-27 | Janet [40%] | 32h |
| 67 | 1.2.4.1.4 | Transfers |  | 10d | 2012-05-15 | 2012-05-28 | 66 | 0d | start no earlier than 2012-02-27 | Janet [40%] | 32h |
| 68 | 1.2.4.1.5 | Early Returns |  | 10d | 2012-05-01 | 2012-05-14 | 65 | 0d | start no earlier than 2012-02-27 | Ross [40%] | 32h |
| 69 | 1.2.4.1.6 | Wait List |  | 10d | 2012-05-15 | 2012-05-28 | 68 | 0d | start no earlier than 2012-02-27 | Ross [40%] | 32h |
| 70 | 1.2.4.1.7 | As-Is Process Maps completed | milestone | 0d | 2012-05-28 | 2012-05-28 | 64, 65, 66, 67, 68, 69 | 0d |  |  |  |
| 71 | 1.2.4.2 | **Data Catagories that are tracked between systems** |  | 20d | 2012-05-29 | 2012-06-25 | 63 | 0d |  |  | 192h |
| 72 | 1.2.4.2.1 | Housing |  | 20d | 2012-05-29 | 2012-06-25 |  | 0d | start no earlier than 2012-03-26 | Ross [40%] | 64h |
| 73 | 1.2.4.2.2 | Biographical |  | 20d | 2012-05-29 | 2012-06-25 |  | 0d | start no earlier than 2012-03-26 | Janet [40%] | 64h |
| 74 | 1.2.4.2.3 | Preferences |  | 20d | 2012-05-29 | 2012-06-25 |  | 0d | start no earlier than 2012-03-26 | Ross [40%] | 64h |
| 75 | 1.2.4.3 | Dual Entry areas / Pain Points |  | 20d | 2012-05-29 | 2012-06-25 | 63 | 0d | start no earlier than 2012-03-26 | Janet [40%] | 64h |
| 76 | 1.2.4.4 | Project Wiki |  | 20d | 2012-05-29 | 2012-06-25 | 63 | 0d | start no earlier than 2012-03-26 | Ross [40%] | 64h |
| 77 | 1.2.5 | Review with Project Team, Stakeholders |  | 5d | 2012-06-26 | 2012-07-02 | 62 | 0d |  |  |  |
| 78 | 1.2.6 | Discovery Phase Completed | milestone | 0d | 2012-07-02 | 2012-07-02 | 77 | 0d |  |  |  |
| 79 | 1.3 | Define Phase |  | 50d | 2012-07-03 | 2012-09-10 | 78 | 0d |  |  |  |
| 80 | 1.4 | Design Phase |  | 50d | 2012-09-11 | 2012-11-19 | 79 | 0d |  |  |  |

Notes:
- 63: Need to show calendar and stakeholders
- 71: Data Catagories for CBord and for MITSIS
